# کسب دانش فنی و تولید بخشی از مواد شیمیایی پر مصرف صنعت نفت و گاز

Schedule from MS Project, 2020-01-21 to 2021-09-22, status date 2021-03-20, A marks actual dates.

## Calendars

- Standard: Mon-Sun 08:00-12:00, 13:00-17:00. Exceptions (off unless hours are given): 2020-03-19 to 2020-04-03 (تعطیلات نوروز 99), 2021-03-19 to 2021-04-02 (تعطیلات نوروز 1400).

## Schedule

| ID | WBS | Task | Type | Duration | Start | Finish | Predecessors | Complete | Remaining | Total slack | Free slack | Constraint | تاریخ شروع شمسی | تاریخ پایان شمسی |
| --- | --- | --- | --- | --- | --- | --- | --- | --- | --- | --- | --- | --- | --- | --- |
| 1 | 1 | **کسب دانش فنی و تولید ماده نشاسته حفاری** |  | 580d | 2020-01-21 A | 2021-09-22 |  | 27% | 422.75d | 0d |  |  | 98/11/1 | 100/6/31 |
| 2 | 1.1 | شروع | milestone | 0d | 2020-01-21 A | 2020-01-21 A |  | 100% |  |  |  |  | 98/11/1 | 98/11/1 |
| 3 | 1.2 | **فاز آزمایشگاهی** |  | 580d | 2020-01-21 A | 2021-09-22 |  | 66% | 196.22d | 0d |  |  | 98/11/1 | 100/6/31 |
| 4 | 1.2.1 | **طراحی آزمایش** |  | 215d | 2020-01-21 A | 2020-09-07 A |  | 100% |  |  |  |  | 98/11/1 | 99/6/17 |
| 5 | 1.2.1.1 | مرور فاز آزمایشگاهی |  | 45d | 2020-01-21 A | 2020-03-05 A | 2 | 100% |  |  |  |  | 98/11/1 | 98/12/15 |
| 6 | 1.2.1.2 | طراحی و انجام فاز آزمایشگاهی |  | 30d | 2020-03-06 A | 2020-04-20 A | 5 | 100% |  |  |  |  | 98/12/16 | 99/2/1 |
| 7 | 1.2.1.3 | آنالیز نمونه |  | 45d | 2020-04-21 A | 2020-06-04 A | 6 | 100% |  |  |  |  | 99/2/2 | 99/3/15 |
| 8 | 1.2.1.4 | انجام تست های کارایی اولیه با استفاده از خرید خدمت |  | 30d | 2020-06-05 A | 2020-07-04 A | 7 | 100% |  |  |  |  | 99/3/16 | 99/4/14 |
| 9 | 1.2.1.5 | بهینه سازی فاز آزمایشگاهی |  | 10d | 2020-07-05 A | 2020-07-14 A | 8 | 100% |  |  |  |  | 99/4/15 | 99/4/24 |
| 10 | 1.2.1.6 | آنالیز نمونه |  | 35d | 2020-07-15 A | 2020-08-18 A | 9 | 100% |  |  |  |  | 99/4/25 | 99/5/28 |
| 11 | 1.2.1.7 | انجام تست های کارایی تکمیلی |  | 20d | 2020-08-19 A | 2020-09-07 A | 10 | 100% |  |  |  |  | 99/5/29 | 99/6/17 |
| 12 | 1.2.2 | **تجهیز آزمایشگاه کنترل کیفی** |  | 580d | 2020-01-21 A | 2021-09-22 |  | 57% | 249.62d | 0d |  |  | 98/11/1 | 100/6/31 |
| 13 | 1.2.2.1 | رولر آون |  | 90d | 2020-01-21 A | 2020-05-05 A | 5SS | 100% |  |  |  |  | 98/11/1 | 99/2/16 |
| 14 | 1.2.2.2 | همزن مکانیکی |  | 90d | 2020-01-21 A | 2020-05-05 A | 13SS | 100% |  |  |  |  | 98/11/1 | 99/2/16 |
| 15 | 1.2.2.3 | فیلترپرس |  | 90d | 2020-01-21 A | 2020-05-05 A | 14SS | 100% |  |  |  |  | 98/11/1 | 99/2/16 |
| 16 | 1.2.2.4 | ویسکومتر |  | 90d | 2020-07-05 A | 2020-10-02 A | 8, 15 | 100% |  |  |  |  | 99/4/15 | 99/7/11 |
| 17 | 1.2.2.5 | سایر تجهیزات |  | 430d | 2020-07-05 A | 2021-09-22 | 16SS | 21% | 340d | 0d |  | finish no earlier than 2021-09-22 | 99/4/15 | 100/6/31 |
| 18 | 1.3 | **فاز پایلوت** |  | 396d | 2020-08-08 A | 2021-09-22 |  | 17% | 329.53d | 0d |  |  | 99/5/18 | 100/6/31 |
| 19 | 1.3.1 | **تامین تجهیزات سنتز** |  | 323d | 2020-08-08 A | 2021-07-11 |  | 8% | 296.85d | 73d |  |  | 99/5/18 | 100/4/20 |
| 20 | 1.3.1.1 | **طراحی پایه** |  | 318d | 2020-08-08 A | 2021-07-06 |  | 5% | 303d | 78d |  |  | 99/5/18 | 100/4/15 |
| 21 | 1.3.1.1.1 | بخش فرایند |  | 318d | 2020-08-08 A | 2021-07-06 | 10SS+24d | 5% | 303d | 78d | 0d | finish no earlier than 2021-07-06 | 99/5/18 | 100/4/15 |
| 22 | 1.3.1.1.2 | بخش مکانیک |  | 318d | 2020-08-08 A | 2021-07-06 | 21SS | 5% | 303d | 78d | 0d | finish no earlier than 2021-07-06 | 99/5/18 | 100/4/15 |
| 23 | 1.3.1.1.3 | برق و ابزار دقیق |  | 318d | 2020-08-08 A | 2021-07-06 | 22SS | 5% | 303d | 0d |  | finish no earlier than 2021-07-06 | 99/5/18 | 100/4/15 |
| 24 | 1.3.1.2 | **طراحی تفصیلی** |  | 308d | 2020-08-23 A | 2021-07-11 |  | 17% | 254.12d | 73d |  |  | 99/6/2 | 100/4/20 |
| 25 | 1.3.1.2.1 | بخش مکانیک، برق و ابزار دقیق |  | 35d | 2020-08-23 A | 2021-07-11 | 23 | 86% | 5d | 73d | 0d | finish no earlier than 2021-07-11 | 99/6/2 | 100/4/20 |
| 26 | 1.3.1.2.2 | بخش طراحی فرایند و گزارش تفصیلی |  | 308d | 2020-08-23 A | 2021-07-11 | 25SS | 10% | 278d | 73d |  | finish no earlier than 2021-07-11 | 99/6/2 | 100/4/20 |

| ID | WBS | Task | Type | Duration | Start | Finish | Predecessors | Complete | Remaining | Total slack | Free slack | Constraint | تاریخ شروع شمسی | تاریخ پایان شمسی |
| --- | --- | --- | --- | --- | --- | --- | --- | --- | --- | --- | --- | --- | --- | --- |
| 27 | 1.3.2 | **خرید/ ساخت تجهیزات** |  | 288d | 2020-09-22 A | 2021-07-21 |  | 26% | 213.28d | 63d |  |  | 99/7/1 | 100/4/30 |
| 28 | 1.3.2.1 | انعقاد قرارداد ساخت |  | 75d | 2020-09-22 A | 2020-12-05 A | 26 | 100% |  |  |  |  | 99/7/1 | 99/9/15 |
| 29 | 1.3.2.2 | نظارت بر ساخت و بازرسی فنی |  | 273d | 2020-10-07 A | 2021-07-21 | 28SS+15d | 22% | 213d | 63d | 0d | finish no earlier than 2021-07-21 | 99/7/16 | 100/4/30 |
| 30 | 1.3.2.3 | تحویل تجهیزات |  | 288d | 2020-09-22 A | 2021-07-21 | 28SS | 10% | 258d | 63d | 15d | finish no earlier than 2021-07-21 | 99/7/1 | 100/4/30 |
| 31 | 1.3.3 | **تامین مواد شیمیایی و مصرفی مورد نیاز** |  | 284d | 2020-10-07 A | 2021-08-01 | 30SS | 21% | 224d | 52d |  |  | 99/7/16 | 100/5/10 |
| 32 | 1.3.3.1 | قطعات مکانیکی |  | 284d | 2020-10-07 A | 2021-08-01 | 29SS | 21% | 224d | 52d | 0d | finish no earlier than 2021-08-01 | 99/7/16 | 100/5/10 |
| 33 | 1.3.3.2 | قطعات برقی و ابزار دقیق |  | 284d | 2020-10-07 A | 2021-08-01 | 32SS | 21% | 224d | 52d | 0d | finish no earlier than 2021-08-01 | 99/7/16 | 100/5/10 |
| 34 | 1.3.3.3 | مواد شیمیایی و مصرفی مورد نیاز |  | 284d | 2020-10-07 A | 2021-08-01 | 33SS | 21% | 224d | 52d |  | finish no earlier than 2021-08-01 | 99/7/16 | 100/5/10 |
| 35 | 1.3.4 | **نصب و راه اندازی تجهیزات** |  | 80d | 2020-10-22 A | 2021-01-09 |  | 16% | 67.4d |  |  |  | 99/8/1 | 100/5/20 |
| 36 | 1.3.4.1 | ساخت اسکلت آهنی |  | 20d | 2020-10-22 A | 2020-11-10 A | 34SS+15d | 100% |  |  |  |  | 99/8/1 | 99/8/20 |
| 37 | 1.3.4.2 | نصب و راه اندازی اولیه |  | 15d | 2020-11-11 A | 2020-11-25 A | 36, 11 | 100% |  |  |  |  | 99/8/21 | 99/9/5 |
| 38 | 1.3.4.3 | راه اندازی آزمایشی |  | 239d | 2020-11-26 A | 2021-08-06 | 37 | 6% | 224d | 47d | 0d | finish no earlier than 2021-08-06 | 99/9/6 | 100/5/15 |
| 39 | 1.3.4.4 | راه اندازی کامل پایلوت |  | 234d | 2020-12-06 A | 2021-08-11 | 38SS+10d | 13% | 204d | 0d |  | finish no earlier than 2021-08-11 | 99/9/16 | 100/5/20 |
| 40 | 1.3.5 | **تولید نمونه** |  | 246d | 2021-01-05 A | 2021-09-22 |  | 21% | 193.7d | 0d |  |  | 99/10/16 | 100/6/31 |
| 41 | 1.3.5.1 | پیاده سازی طراحی فرایند |  | 25d | 2021-01-05 A | 2021-08-21 | 39 | 60% | 10d | 32d | 0d | finish no earlier than 2021-08-21 | 99/10/16 | 100/5/30 |
| 42 | 1.3.5.2 | آنالیز نمونه |  | 215d | 2021-01-05 A | 2021-08-22 | 41SS | 7% | 200d | 31d |  | finish no earlier than 2021-08-22 | 99/10/16 | 100/5/31 |
| 43 | 1.3.5.3 | تایید نمونه توسط آزمایشگاه مرجع |  | 30d | 2021-01-20 A | 2021-02-18 A | 42 | 100% |  |  |  |  | 99/11/1 | 99/11/30 |
| 44 | 1.3.5.4 | بهینه سازی فرایند |  | 220d | 2021-01-20 A | 2021-09-11 | 43SS | 14% | 190d | 11d |  | finish no earlier than 2021-09-11 | 99/11/1 | 100/6/20 |
| 45 | 1.3.5.5 | آنالیز نهایی |  | 4d | 2021-09-12 A | 2021-09-15 A | 44SS | 100% |  |  |  |  | 100/6/21 | 100/6/24 |
| 46 | 1.3.5.6 | انتقال پایلوت به محل نصب نهایی |  | 7d | 2021-09-16 A | 2021-09-22 A | 45, 17 | 100% |  |  |  |  | 100/6/25 | 100/6/31 |
| 47 | 1.3.5.7 | تهیه و تنظیم گزارش پایانی |  | 7d | 2021-09-16 A | 2021-09-22 A | 46SS | 100% |  |  |  |  | 100/6/25 | 100/6/31 |
| 48 | 1.3.5.8 | پایان | milestone | 0d | 2021-09-22 A | 2021-09-22 A | 47 | 100% |  |  |  | start no earlier than 2021-03-05 | 100/6/31 | 100/6/31 |
